| id | name | startDate | endDate | priority | barScale | progress | type | parentId | dependencies |
| --- | --- | --- | --- | --- | --- | --- | --- | --- | --- |
| 1 | Retail Store Opening | 2026-06-01T00:00:00.000Z | 2026-11-30T00:00:00.000Z | medium | 1 | 0 | group |  |  |
| 2 | Write business plan & concept | 2026-06-01T00:00:00.000Z | 2026-06-15T00:00:00.000Z | medium | 1 | 0 | task | 1 |  |
| 3 | Set startup budget & financing | 2026-06-11T00:00:00.000Z | 2026-07-02T00:00:00.000Z | high | 1 | 0 | task | 1 |  |
| 4 | Register entity & bank account | 2026-06-15T00:00:00.000Z | 2026-06-25T00:00:00.000Z | medium | 1 | 0 | task | 1 |  |
| 5 | Scout & compare retail locations | 2026-06-15T00:00:00.000Z | 2026-07-13T00:00:00.000Z | medium | 1 | 0 | task | 1 | 2 FS |
| 6 | Sign lease | 2026-07-13T00:00:00.000Z | 2026-07-14T00:00:00.000Z | high | 1 | 0 | milestone | 1 | 5 FS |
| 7 | Permits, licenses & insurance | 2026-07-14T00:00:00.000Z | 2026-08-18T00:00:00.000Z | high | 1 | 0 | task | 1 | 6 FS |
| 8 | Finalize store design & layout | 2026-07-14T00:00:00.000Z | 2026-07-29T00:00:00.000Z | medium | 1 | 0 | task | 1 | 6 FS |
| 9 | Buildout & fit-out construction | 2026-07-29T00:00:00.000Z | 2026-09-14T00:00:00.000Z | high | 1 | 0 | task | 1 | 8 FS |
| 10 | Open supplier & vendor accounts | 2026-08-20T00:00:00.000Z | 2026-09-03T00:00:00.000Z | medium | 1 | 0 | task | 1 |  |
| 11 | Select & set up POS/payments | 2026-08-30T00:00:00.000Z | 2026-09-17T00:00:00.000Z | medium | 1 | 0 | task | 1 |  |
| 12 | Place first inventory order | 2026-09-03T00:00:00.000Z | 2026-09-10T00:00:00.000Z | medium | 1 | 0 | task | 1 | 10 FS |
| 13 | Install fixtures & signage | 2026-09-14T00:00:00.000Z | 2026-09-26T00:00:00.000Z | medium | 1 | 0 | task | 1 | 9 FS |
| 14 | Hire store staff | 2026-09-19T00:00:00.000Z | 2026-10-10T00:00:00.000Z | medium | 1 | 0 | task | 1 |  |
| 15 | Receive inventory shipment | 2026-09-26T00:00:00.000Z | 2026-10-04T00:00:00.000Z | medium | 1 | 0 | task | 1 | 12 FS |
| 16 | Marketing & local launch buzz | 2026-09-29T00:00:00.000Z | 2026-11-03T00:00:00.000Z | medium | 1 | 0 | task | 1 |  |
| 17 | Merchandise stock & set displays | 2026-10-04T00:00:00.000Z | 2026-10-14T00:00:00.000Z | medium | 1 | 0 | task | 1 | 15 FS |
| 18 | Train staff on POS & procedures | 2026-10-10T00:00:00.000Z | 2026-10-20T00:00:00.000Z | medium | 1 | 0 | task | 1 | 14 FS |
| 19 | Soft opening | 2026-11-09T00:00:00.000Z | 2026-11-10T00:00:00.000Z | medium | 1 | 0 | milestone | 1 | 18 FS |
| 20 | Grand opening | 2026-11-19T00:00:00.000Z | 2026-11-20T00:00:00.000Z | high | 1 | 0 | milestone | 1 | 19 FS |
| 21 | Post-opening review | 2026-11-20T00:00:00.000Z | 2026-11-30T00:00:00.000Z | medium | 1 | 0 | task | 1 | 20 FS |
